# Breve Proyecto Cinematográfico

How a schedule from MS Project changed from version to version. A marks actual dates.

## Version 1 (data date 2008-06-20, saved 2014-02-13, file ProAV-Unidad4-BreveProyectoCinematografico18.mpp)

| ID | WBS | Task | Duration | Start | Finish | Predecessors | Complete | Total float | Constraint |
| --- | --- | --- | --- | --- | --- | --- | --- | --- | --- |
| 1 | 1 | **Preproducción** | 59.75d | 2008-03-03 A | 2008-05-23 A |  | 100% |  |  |
| 2 |  | Revisión del guión literario | 3.75d | 2008-03-03 A | 2008-03-06 A |  | 100% |  |  |
| 3 |  | División y planificación del guión literario | 6.51d | 2008-03-07 A | 2008-03-17 A | 2 | 100% |  |  |
| 4 |  | Desarrollo del guión técnico | 0.89mo | 2008-03-18 A | 2008-04-10 A | 3 | 100% |  |  |
| 5 |  | Revisión del guión técnico | 0.95w | 2008-04-11 A | 2008-04-17 A | 4 | 100% |  |  |
| 6 |  | Búsqueda de exteriores | 1.75w | 2008-04-18 A | 2008-04-30 A | 5 | 100% |  |  |
| 7 |  | Selección de exteriores | 0.95w | 2008-05-02 A | 2008-05-08 A | 6 | 100% |  |  |
| 8 |  | Realización de pruebas a actores | 0.95w | 2008-05-09 A | 2008-05-15 A | 7 | 100% |  |  |
| 9 |  | Solicitud de permisos de rodaje | 0.95w | 2008-05-16 A | 2008-05-22 A | 8 | 100% |  |  |
| 10 |  | Reserva de equipo de rodaje | 2.88d | 2008-05-20 A | 2008-05-23 A | 9FS-5% | 100% |  |  |
| 11 |  | Reserva de equipo de sonido | 3.25d | 2008-05-20 A | 2008-05-23 A | 10SS | 100% |  |  |
| 12 |  | ¡Preproducción completada! | 0d | 2008-05-23 A | 2008-05-23 A | 11 | 100% |  |  |
| 13 | 1.12 | **Reunión de seguimiento** | 45.12d | 2008-03-10 A | 2008-05-12 A |  | 100% |  |  |
| 14 |  | Reunión de seguimiento 1 | 1h | 2008-03-10 A | 2008-03-10 A |  | 100% |  | start no earlier than 2008-03-10 |
| 15 |  | Reunión de seguimiento 2 | 1h | 2008-03-17 A | 2008-03-17 A |  | 100% |  | start no earlier than 2008-03-17 |
| 16 |  | Reunión de seguimiento 3 | 1h | 2008-03-24 A | 2008-03-24 A |  | 100% |  | start no earlier than 2008-03-24 |
| 17 |  | Reunión de seguimiento 4 | 1h | 2008-03-31 A | 2008-03-31 A |  | 100% |  | start no earlier than 2008-03-31 |
| 18 |  | Reunión de seguimiento 5 | 1h | 2008-04-07 A | 2008-04-07 A |  | 100% |  | start no earlier than 2008-04-07 |
| 19 |  | Reunión de seguimiento 6 | 1h | 2008-04-14 A | 2008-04-14 A |  | 100% |  | start no earlier than 2008-04-14 |
| 20 |  | Reunión de seguimiento 7 | 1h | 2008-04-21 A | 2008-04-21 A |  | 100% |  | start no earlier than 2008-04-21 |
| 21 |  | Reunión de seguimiento 8 | 1h | 2008-04-28 A | 2008-04-28 A |  | 100% |  | start no earlier than 2008-04-28 |
| 22 |  | Reunión de seguimiento 9 | 1h | 2008-05-05 A | 2008-05-05 A |  | 100% |  | start no earlier than 2008-05-05 |
| 23 |  | Reunión de seguimiento 10 | 1h | 2008-05-12 A | 2008-05-12 A |  | 100% |  | start no earlier than 2008-05-12 |
| 24 | 2 | **Producción** | 52d | 2008-05-26 A | 2008-08-06 | 1 | 28% | 0d |  |
| 25 | 2.1 | **Escena 7** | 5d | 2008-05-26 A | 2008-05-31 A |  | 100% |  |  |
| 26 |  | Escena 7: Instalación de decorados | 1.5d | 2008-05-26 A | 2008-05-27 A |  | 100% |  |  |
| 27 |  | Escena 7: Ensayo | 1d | 2008-05-27 A | 2008-05-28 A | 26 | 100% |  |  |
| 28 |  | Escena 7: Rodaje | 1.25d | 2008-05-28 A | 2008-05-29 A | 27 | 100% |  |  |
| 29 |  | Escena 7: Montaje | 0.75d | 2008-05-30 A | 2008-05-30 A | 28 | 100% |  |  |
| 30 |  | Escena 7: Reproceso | 1d | 2008-05-30 A | 2008-05-31 A | 29 | 100% |  |  |
| 31 | 2.2 | **Escena 3** | 8.75d | 2008-06-02 A | 2008-06-12 A | 25 | 100% |  |  |
| 32 |  | Escena 3: Instalación de decorados | 2.75d | 2008-06-02 A | 2008-06-04 A |  | 100% |  | start no earlier than 2008-05-26 |
| 33 |  | Escena 3: Ensayo | 1.75d | 2008-06-05 A | 2008-06-06 A | 32 | 100% |  |  |
| 34 |  | Escena 3: Rodaje | 1.75d | 2008-06-09 A | 2008-06-10 A | 33 | 100% |  |  |
| 35 |  | Escena 3: Montaje | 1.75d | 2008-06-11 A | 2008-06-12 A | 34 | 100% |  |  |
| 36 |  | Escena 3: Reproceso | 1d | 2008-06-10 A | 2008-06-11 A | 34 | 100% |  |  |
| 37 | 2.3 | **Escena 1** | 8.75d | 2008-06-13 A | 2008-06-25 | 31 | 15% | 0.25d |  |
| 38 |  | Escena 1: Instalación de decorados | 2.75d | 2008-06-13 A | 2008-06-20 |  | 36% | 0.25d |  |
| 39 |  | Escena 1: Ensayo | 1d | 2008-06-20 | 2008-06-23 | 38 |  | 0.25d | start no earlier than 2008-06-18 |
| 40 |  | Escena 1: Rodaje | 1d | 2008-06-23 | 2008-06-24 | 39 |  | 0.25d |  |
| 41 |  | Escena 1: Montaje | 1d | 2008-06-24 | 2008-06-25 | 40 |  | 0.25d |  |
| 42 |  | Escena 1: Reproceso | 1d | 2008-06-24 | 2008-06-25 | 40 |  | 1d |  |
| 43 | 2.4 | **Escena 2** | 4.25d | 2008-06-25 | 2008-07-02 | 37 |  | 0d |  |
| 44 |  | Escena 2: Instalación de decorados | 1d | 2008-06-25 | 2008-06-26 |  |  | 0.25d |  |
| 45 |  | Escena 2: Ensayo | 1d | 2008-06-26 | 2008-06-27 | 44 |  | 0.25d |  |
| 46 |  | Escena 2: Rodaje | 1d | 2008-06-27 | 2008-06-30 | 45 |  | 0.5d |  |
| 47 |  | Escena 2: Montaje | 1d | 2008-07-01 | 2008-07-01 | 46 |  | 0d |  |
| 48 |  | Escena 2: Reproceso | 1d | 2008-07-01 | 2008-07-02 | 47 |  | 0d |  |
| 49 | 2.5 | **Escena 5** | 5d | 2008-07-02 | 2008-07-08 | 43 |  | 0.2d |  |
| 50 |  | Escena 5: Instalación de decorados | 2d | 2008-07-02 | 2008-07-03 |  |  | 0.2d |  |
| 51 |  | Escena 5: Ensayo | 1d | 2008-07-04 | 2008-07-04 | 50 |  | 0.2d |  |
| 52 |  | Escena 5: Rodaje | 1d | 2008-07-07 | 2008-07-07 | 51 |  | 0.2d |  |
| 53 |  | Escena 5: Montaje | 1d | 2008-07-08 | 2008-07-08 | 52 |  | 0.2d |  |
| 54 |  | Escena 5: Reproceso | 1d | 2008-07-07 | 2008-07-08 | 52 |  | 1d |  |
| 55 | 2.6 | **Escena 6** | 10d | 2008-07-09 | 2008-07-23 | 49 |  | 0d |  |
| 56 |  | Escena 6: Instalación de decorados | 4d | 2008-07-09 | 2008-07-14 |  |  | 0.2d |  |
| 57 |  | Escena 6: Ensayo | 3d | 2008-07-15 | 2008-07-17 | 56 |  | 0.2d |  |
| 58 |  | Escena 6: Rodaje | 1d | 2008-07-18 | 2008-07-18 | 57 |  | 0.2d |  |
| 59 |  | Escena 6: Montaje | 1.8d | 2008-07-21 | 2008-07-22 | 58 |  | 0.2d |  |
| 60 |  | Escena 6: Reproceso | 1d | 2008-07-22 | 2008-07-23 | 59 |  | 0d |  |
| 61 | 2.7 | **Escena 8** | 6d | 2008-07-23 | 2008-07-31 | 55 |  | 0d |  |
| 62 |  | Escena 8: Instalación de decorados | 1.8d | 2008-07-23 | 2008-07-24 |  |  | 0.3d |  |
| 63 |  | Escena 8: Ensayo | 2d | 2008-07-24 | 2008-07-28 | 62 |  | 0.3d |  |
| 64 |  | Escena 8: Rodaje | 1d | 2008-07-28 | 2008-07-29 | 63 |  | 0.3d |  |
| 65 |  | Escena 8: Montaje | 0.9d | 2008-07-29 | 2008-07-30 | 64 |  | 0.3d |  |
| 66 |  | Escena 8: Reproceso | 1d | 2008-07-30 | 2008-07-31 | 65 |  | 0d |  |
| 67 | 2.8 | **Escena 4** | 4d | 2008-07-31 | 2008-08-06 | 61 |  | 0d |  |
| 68 |  | Escena 4: Instalación de decorados | 1.5d | 2008-07-31 | 2008-08-01 |  |  | 0.25d |  |
| 69 |  | Escena 4: Ensayo | 4h | 2008-08-01 | 2008-08-01 | 68 |  | 0.25d |  |
| 70 |  | Escena 4: Rodaje | 2h | 2008-08-04 | 2008-08-04 | 69 |  | 0.25d |  |

| ID | WBS | Task | Duration | Start | Finish | Predecessors | Total float |
| --- | --- | --- | --- | --- | --- | --- | --- |
| 71 |  | Escena 4: Montaje | 1.5d | 2008-08-04 | 2008-08-05 | 70 | 0.25d |
| 72 |  | Escena 4: Reproceso | 1d | 2008-08-05 | 2008-08-06 | 71 | 0d |
| 73 | 3 | **Post-producción** | 72.38d | 2008-08-06 | 2008-11-14 | 24 | 0d |
| 74 |  | Ajustes previos | 9d | 2008-08-06 | 2008-08-18 |  | 0d |
| 75 |  | Grabación BS previa | 8.25d | 2008-08-19 | 2008-08-29 | 74 | 0d |
| 76 |  | Edición en papel | 6.88d | 2008-08-29 | 2008-09-09 | 75 | 0d |
| 77 |  | Primera edición | 5d | 2008-09-09 | 2008-09-16 | 76 | 0d |
| 78 |  | Ajustes en la edición | 10d | 2008-09-16 | 2008-09-30 | 77 | 0d |
| 79 |  | Presentación a cliente | 1d | 2008-09-30 | 2008-10-01 | 78 | 0d |
| 80 |  | Inserción banda sonora final | 9d | 2008-10-01 | 2008-10-14 | 79 | 0d |
| 81 |  | Adición de cabeceras y créditos | 1w | 2008-10-14 | 2008-10-21 | 80 | 0d |
| 82 |  | Adición de banda musical final | 16d | 2008-10-21 | 2008-11-12 | 81 | 0d |
| 83 |  | Impresión de negativos | 3d | 2008-10-21 | 2008-10-24 | 82SS | 0d |
| 84 |  | Copia de la banda sonora final | 12d | 2008-10-24 | 2008-11-11 | 83 | 0d |
| 85 |  | Archivado de imagen y sonido finales | 2d | 2008-11-11 | 2008-11-13 | 84 | 0d |
| 86 |  | Entrega al distribuidor | 1d | 2008-11-13 | 2008-11-14 | 85 | 0d |

## Version 2 (data date 2016-06-28, saved 2015-01-14, file P-001.mpp)

Last finish 2008-11-14 → 2016-10-14 (+2891d). Complete tasks 31 → 20.

Removed: 13 Reunión de seguimiento; 14 Reunión de seguimiento 1; 15 Reunión de seguimiento 2; 16 Reunión de seguimiento 3; 17 Reunión de seguimiento 4; 18 Reunión de seguimiento 5; 19 Reunión de seguimiento 6; 20 Reunión de seguimiento 7; 21 Reunión de seguimiento 8; 22 Reunión de seguimiento 9; 23 Reunión de seguimiento 10; 25 Escena 7; 26 Escena 7: Instalación de decorados; 27 Escena 7: Ensayo; 28 Escena 7: Rodaje; 29 Escena 7: Montaje; 30 Escena 7: Reproceso; 49 Escena 5; 50 Escena 5: Instalación de decorados; 51 Escena 5: Ensayo; 52 Escena 5: Rodaje; 53 Escena 5: Montaje; 54 Escena 5: Reproceso; 55 Escena 6; 56 Escena 6: Instalación de decorados; 57 Escena 6: Ensayo; 58 Escena 6: Rodaje; 59 Escena 6: Montaje; 60 Escena 6: Reproceso; 61 Escena 8; 62 Escena 8: Instalación de decorados; 63 Escena 8: Ensayo; 64 Escena 8: Rodaje; 65 Escena 8: Montaje; 66 Escena 8: Reproceso; 67 Escena 4; 68 Escena 4: Instalación de decorados; 69 Escena 4: Ensayo; 70 Escena 4: Rodaje; 71 Escena 4: Montaje; 72 Escena 4: Reproceso; 75 Grabación BS previa; 76 Edición en papel; 81 Adición de cabeceras y créditos

Changed:

| ID | Task | Start | Finish | Duration | Complete | Total float | Predecessors | Other |
| --- | --- | --- | --- | --- | --- | --- | --- | --- |
| 1 | **Preproducción** | 2008-03-03 A → 2016-03-07 A (+2926d) | 2008-05-23 A → 2016-06-10 A (+2940d) | 59.75d → 70d |  |  |  | baseline start 2008-03-03 → 2016-03-07; baseline finish 2008-05-27 → 2016-06-10 |
| 2 | Revisión del guión literario | 2008-03-03 A → 2016-03-07 A (+2926d) | 2008-03-06 A → 2016-03-10 A (+2926d) | 3.75d → 4d |  |  |  | resources Scott Cooper [53.3%]; Clair Hector [106.7%] → Jeremy Alfaro; baseline start 2008-03-03 → 2016-03-07; baseline finish 2008-03-06 → 2016-03-10 |
| 3 | División y planificación del guión literario | 2008-03-07 A → 2016-03-11 A (+2926d) | 2008-03-17 A → 2016-03-24 A (+2929d) | 6.51d → 10d |  |  |  | resources Scott Cooper [158.3%]; Johnathan Perrera [158.3%]; Clair Hector [156.8%] → Clara Blanco; baseline start 2008-03-07 → 2016-03-11; baseline finish 2008-03-17 → 2016-03-24 |
| 4 | Desarrollo del guión técnico | 2008-03-18 A → 2016-03-25 A (+2929d) | 2008-04-10 A → 2016-04-21 A (+2933d) | 0.89mo → 1mo |  |  |  | resources Scott Cooper [152.1%]; Kim Yoshida [152.1%]; Johnathan Perrera [152.1%] → Jeremy Alfaro; baseline start 2008-03-17 → 2016-03-24; baseline finish 2008-04-15 → 2016-04-21 |
| 5 | Revisión del guión técnico | 2008-04-11 A → 2016-04-22 A (+2933d) | 2008-04-17 A → 2016-04-29 A (+2934d) | 0.95w → 1.2w |  |  |  | resources Clair Hector [105.3%]; Scott Cooper [105.3%] → Clara Blanco; baseline start 2008-04-15 → 2016-04-21; baseline finish 2008-04-22 → 2016-04-28 |
| 6 | Búsqueda de exteriores | 2008-04-18 A → 2016-05-02 A (+2936d) | 2008-04-30 A → 2016-05-13 A (+2935d) | 1.75w → 2w |  |  |  | resources Jo Brown [102.9%]; Jan Miksovsky [102.9%]; Max Benson [102.9%]; Viajes [0.1%] → José Bolaños; Viáticos [0.1%]; baseline start 2008-04-22 → 2016-04-28; baseline finish 2008-05-06 → 2016-05-12 |
| 7 | Selección de exteriores | 2008-05-02 A → 2016-05-16 A (+2936d) | 2008-05-08 A → 2016-05-20 A (+2934d) | 0.95w → 1w |  |  |  | resources Scott Cooper [105.6%]; Clair Hector [105.6%]; Max Benson [105.3%] → Jeremy Alfaro; baseline start 2008-05-06 → 2016-05-12; baseline finish 2008-05-13 → 2016-05-19 |
| 8 | Realización de pruebas a actores | 2008-05-09 A → 2016-05-23 A (+2936d) | 2008-05-15 A → 2016-05-23 A (+2930d) | 0.95w → 1d |  |  |  | resources Clair Hector [105.6%]; Scott Cooper [105.6%]; Doug Hampton [52.6%]; Catering [0.1%] → Clara Blanco; Catering [0.1%]; baseline start 2008-05-13 → 2016-05-19; baseline finish 2008-05-20 → 2016-05-26 |
| 9 | Solicitud de permisos de rodaje | 2008-05-16 A → 2016-05-24 A (+2930d) | 2008-05-22 A → 2016-05-31 A (+2931d) | 0.95w → 1.2w |  |  |  | resources Kim Yoshida [105.3%] → Kelly Borbón; baseline start 2008-05-20 → 2016-05-26; baseline finish 2008-05-27 → 2016-06-02 |
| 10 | Reserva de equipo de rodaje | 2008-05-20 A → 2016-06-01 A (+2934d) | 2008-05-23 A → 2016-06-06 A (+2936d) | 2.88d → 4d |  |  | 9FS-5% → 9 | resources Jan Miksovsky [104.3%]; Eric Lang [52.2%] → Jenny Solera; baseline start 2008-05-22 → 2016-06-02; baseline finish 2008-05-27 → 2016-06-07 |
| 11 | Reserva de equipo de sonido | 2008-05-20 A → 2016-06-07 A (+2940d) | 2008-05-23 A → 2016-06-10 A (+2940d) | 3.25d → 4d |  |  | 10SS → 10 | resources Eric Lang [80.8%] → Erick Lagos; baseline start 2008-05-22 → 2016-06-07; baseline finish 2008-05-27 → 2016-06-10 |
| 12 | ¡Preproducción completada! | 2008-05-23 A → 2016-06-10 A (+2940d) | 2008-05-23 A → 2016-06-10 A (+2940d) |  |  |  |  | baseline start 2008-05-27 → 2016-06-10; baseline finish 2008-05-27 → 2016-06-10 |
| 13 | **Producción** | 2008-05-26 A → 2016-06-13 A (+2940d) | 2008-08-06 → 2016-07-11 (+2896d) | 52d → 21d | 28% → 72% |  |  | baseline start 2008-05-27 → 2016-06-10; baseline finish 2008-08-06 → 2016-07-05 |
| 14 | **Escena 2** | 2008-06-25 → 2016-06-13 A (+2910d) | 2008-07-02 → 2016-06-25 A (+2915d) | 4.25d → 10d | 0% → 100% | 0d → none | 26 → none | baseline start 2008-06-17 → 2016-06-10; baseline finish 2008-06-21 → 2016-06-17 |
| 15 | Escena 2: Instalación de decorados | 2008-06-25 → 2016-06-13 A (+2910d) | 2008-06-26 → 2016-06-14 A (+2910d) | 1d → 2d | 0% → 100% | 0.25d → none |  | resources Jo Brown; Megan Sherman; Electricista → Electricista; baseline start 2008-06-17 → 2016-06-10; baseline finish 2008-06-17 → 2016-06-13 |
| 16 | Escena 2: Ensayo | 2008-06-26 → 2016-06-15 A (+2911d) | 2008-06-27 → 2016-06-15 A (+2910d) |  | 0% → 100% | 0.25d → none |  | resources Scott Cooper; Doug Hampton [50%]; David Campbell; Anne L. Paper; Jan Miksovsky → Jenny Solera; baseline start 2008-06-18 → 2016-06-13; baseline finish 2008-06-18 → 2016-06-14 |
| 17 | Escena 2: Rodaje | 2008-06-27 → 2016-06-16 A (+2911d) | 2008-06-30 → 2016-06-17 A (+2909d) | 1d → 1.5d | 0% → 100% | 0.5d → none |  | resources Scott Cooper; Doug Hampton [50%]; Anne L. Paper; Tim O'Brien; Frank Lee; Keith Harris; Ted Bremer; Cámara de 16 mm [200%]; Foco de 500 watios [300%]; Jan Miksovsky; David Campbell; Trípode de cámara; Grúa; Dolly; Película de 16 mm [5 100 metros] → Cámara de 16 mm [600%]; Foco de 500 watios [600%]; Megan Surprise; Trípode de cámara [600%]; Película de 16 mm [6 100 metros]; baseline start 2008-06-18 → 2016-06-14; baseline finish 2008-06-19 → 2016-06-15 |
| 18 | Escena 2: Montaje | 2008-07-01 → 2016-06-17 A (+2908d) | 2008-07-01 → 2016-06-24 A (+2915d) | 1d → 5d | 0% → 100% | 0d → none |  | resources Jo Brown; Megan Sherman; Electricista → Electricista; baseline start 2008-06-20 → 2016-06-15; baseline finish 2008-06-20 → 2016-06-16 |
| 19 | Escena 2: Reproceso | 2008-07-01 → 2016-06-24 A (+2915d) | 2008-07-02 → 2016-06-25 A (+2915d) |  | 0% → 100% | 0d → none |  | baseline start 2008-06-20 → 2016-06-16; baseline finish 2008-06-21 → 2016-06-17 |
| 20 | **Escena 3** | 2008-06-02 A → 2016-06-27 A (+2947d) | 2008-06-12 A → 2016-07-05 (+2945d) | 8.75d → 6.5d | 100% → 87% | none → 0d | Escena 7 → 14 | baseline start 2008-06-03 → 2016-06-17; baseline finish 2008-06-06 → 2016-06-27 |
| 21 | Escena 3: Instalación de decorados | 2008-06-02 A → 2016-06-27 A (+2947d) | 2008-06-04 A → 2016-06-27 A (+2945d) | 2.75d → 1d |  |  |  | constraint start no earlier than 2008-05-26 → none; resources Jo Brown [222.2%]; Max Benson [222.2%]; Electricista [54.5%] → Electricista; baseline start 2008-06-03 → 2016-06-17; baseline finish 2008-06-03 → 2016-06-20 |
| 22 | Escena 3: Ensayo | 2008-06-05 A → 2016-06-28 A (+2945d) | 2008-06-06 A → 2016-06-29 A (+2945d) |  |  |  |  | resources Scott Cooper [114.3%]; Jo Brown [114.3%]; Eric Miller [114.3%]; Jim Hance [114.3%]; Anne L. Paper [114.3%]; Joseph Matthews [114.3%]; Jan Miksovsky [114.3%] → Jeremy Alfaro; Patricia López; baseline start 2008-06-04 → 2016-06-20; baseline finish 2008-06-04 → 2016-06-22 |
| 23 | Escena 3: Rodaje | 2008-06-09 A → 2016-06-29 A (+2942d) | 2008-06-10 A → 2016-07-01 A (+2943d) |  |  |  |  | resources Scott Cooper [114.3%]; Jo Brown [114.3%]; Eric Miller [114.3%]; Jim Hance [114.3%]; Anne L. Paper [114.3%]; Joseph Matthews [114.3%]; Tim O'Brien [114.3%]; Megan Sherman [114.3%]; Doug Hampton [57.1%]; Keith Harris [114.3%]; Cámara de 16 mm [228.6%]; Foco de 500 watios [457.1%]; Dolly [114.3%]; Frank Lee [114.3%]; Jan Miksovsky [114.3%]; Ted Bremer [114.3%]; Trípode de cámara [114.3%]; Película de 16 mm [5.71 100 metros] → Megan Surprise; Cámara de 16 mm; Foco de 500 watios; Trípode de cámara; Película de 16 mm [5.71 100 metros]; baseline start 2008-06-05 → 2016-06-22; baseline finish 2008-06-05 → 2016-06-24 |
| 24 | Escena 3: Montaje | 2008-06-11 A → 2016-07-01 A (+2942d) | 2008-06-12 A → 2016-07-05 A (+2945d) | 1.75d → 2d |  |  |  | resources Jo Brown [218.2%]; Max Benson [218.2%]; Electricista [57.1%] → Electricista; baseline start 2008-06-06 → 2016-06-24; baseline finish 2008-06-06 → 2016-06-27 |
| 25 | Escena 3: Reproceso | 2008-06-10 A → 2016-07-01 (+2943d) | 2008-06-11 A → 2016-07-02 (+2943d) |  | 100% → 0% | none → 1d |  | baseline start 2008-06-05 → 2016-06-24; baseline finish 2008-06-06 → 2016-06-25 |
| 26 | **Escena 1** | 2008-06-13 A → 2016-07-05 (+2944d) | 2008-06-25 → 2016-07-11 (+2938d) | 8.75d → 4.5d | 15% → 0% | 0.25d → 0d |  | baseline start 2008-06-09 → 2016-06-28; baseline finish 2008-06-16 → 2016-07-05 |
| 27 | Escena 1: Instalación de decorados | 2008-06-13 A → 2016-07-05 (+2944d) | 2008-06-20 → 2016-07-06 (+2938d) | 2.75d → 1.5d | 36% → 0% | 0.25d → 0d |  | resources Jo Brown; Max Benson; Electricista [200%] → Electricista; baseline start 2008-06-09 → 2016-06-28; baseline finish 2008-06-11 → 2016-06-30 |
| 28 | Escena 1: Ensayo | 2008-06-20 → 2016-07-07 (+2939d) | 2008-06-23 → 2016-07-07 (+2936d) | 1d → 0.75d |  | 0.25d → 0d |  | constraint start no earlier than 2008-06-18 → none; resources Scott Cooper; Jo Brown; Paul Borm [50%]; David Campbell; Eric Miller; Sue Jackson; Jan Miksovsky → David Casas; baseline start 2008-06-12 → 2016-06-30; baseline finish 2008-06-12 → 2016-07-01 |
| 29 | Escena 1: Rodaje | 2008-06-23 → 2016-07-07 (+2936d) | 2008-06-24 → 2016-07-08 (+2936d) | 1d → 0.75d |  | 0.25d → 0d |  | resources Scott Cooper; Jo Brown; Paul Borm [50%]; David Campbell; Eric Miller; Sue Jackson; Tim O'Brien; Frank Lee; Megan Sherman; Doug Hampton [50%]; Keith Harris; Ted Bremer; Cámara de 16 mm [300%]; Foco de 500 watios; Jan Miksovsky; Dolly; Trípode de cámara; Película de 16 mm [5 100 metros] → Megan Surprise; Cámara de 16 mm; Foco de 500 watios; Trípode de cámara; Película de 16 mm [6.67 100 metros]; baseline start 2008-06-13 → 2016-07-01; baseline finish 2008-06-13 → 2016-07-04 |
| 30 | Escena 1: Montaje | 2008-06-24 → 2016-07-08 (+2936d) | 2008-06-25 → 2016-07-11 (+2938d) | 1d → 1.5d |  | 0.25d → 0d |  | resources Jo Brown; Max Benson; Electricista [200%] → Electricista; baseline start 2008-06-16 → 2016-07-05; baseline finish 2008-06-16 → 2016-07-05 |
| 31 | Escena 1: Reproceso | 2008-06-24 → 2016-07-08 (+2936d) | 2008-06-25 → 2016-07-09 (+2936d) |  |  |  |  | baseline start 2008-06-13 → 2016-07-04; baseline finish 2008-06-14 → 2016-07-05 |
| 32 | **Post-producción** | 2008-08-06 → 2016-07-12 (+2897d) | 2008-11-14 → 2016-10-14 (+2891d) | 72.38d → 68.25d |  |  |  | baseline start 2008-08-06 → 2016-07-05; baseline finish 2008-12-19 → 2016-10-07 |
| 33 | Ajustes previos | 2008-08-06 → 2016-07-12 (+2897d) | 2008-08-18 → 2016-07-22 (+2895d) | 9d → 8d |  |  |  | resources Laboratorio de edición; Viajes [0.2%] → Laboratorio de edición; Viáticos [0.2%]; Floría Víquez; baseline start 2008-08-06 → 2016-07-05; baseline finish 2008-08-18 → 2016-07-18 |
| 34 | Primera edición | 2008-09-09 → 2016-07-25 (+2876d) | 2008-09-16 → 2016-07-29 (+2873d) |  |  |  | Edición en papel → 33 | resources Clair Hector; Richard Lum → Clara Blanco; Ricardo Brenes; baseline start 2008-09-18 → 2016-07-18; baseline finish 2008-09-24 → 2016-07-25 |
| 35 | Ajustes en la edición | 2008-09-16 → 2016-08-01 (+2876d) | 2008-09-30 → 2016-08-12 (+2873d) |  |  |  |  | resources Clair Hector; Richard Lum; Lisa Garmaise; Kim Yoshida; Laboratorio de edición → Clara Blanco; Ricardo Brenes; Lisa Calero; Kelly Borbón; Laboratorio de edición; baseline start 2008-09-25 → 2016-07-25; baseline finish 2008-10-08 → 2016-08-08 |
| 36 | Presentación a cliente | 2008-09-30 → 2016-08-15 (+2876d) | 2008-10-01 → 2016-08-15 (+2875d) |  |  |  |  | resources Clair Hector; Jo Brown; Mark Hassall [50%]; Scott Cooper [50%]; Catering [0.6%] → Clara Blanco; José Bolaños; Mark O'hara [50%]; Patricia López [50%]; Catering [0.6%]; baseline start 2008-10-09 → 2016-08-08; baseline finish 2008-10-09 → 2016-08-09 |
| 37 | Inserción banda sonora final | 2008-10-01 → 2016-08-16 (+2876d) | 2008-10-14 → 2016-08-26 (+2873d) |  |  |  |  | resources David Campbell; Michael Patten; Scott Cooper → David Casas; Miguel Pattoni; Patricia López; baseline start 2008-10-10 → 2016-08-09; baseline finish 2008-10-22 → 2016-08-22 |
| 38 | Adición de banda musical final | 2008-10-21 → 2016-08-29 (+2869d) | 2008-11-12 → 2016-09-19 (+2868d) |  |  |  | Adición de cabeceras y créditos → 37 | resources Michael Patten → Miguel Pattoni; baseline start 2008-10-30 → 2016-08-22; baseline finish 2008-11-20 → 2016-09-13 |
| 39 | Impresión de negativos | 2008-10-21 → 2016-09-20 (+2891d) | 2008-10-24 → 2016-09-22 (+2890d) |  |  |  | 38SS → 38 | resources Viajes [0.2%] → Viáticos [0.2%]; Floría Víquez; baseline start 2008-11-21 → 2016-09-13; baseline finish 2008-11-25 → 2016-09-16 |
| 40 | Copia de la banda sonora final | 2008-10-24 → 2016-09-23 (+2891d) | 2008-11-11 → 2016-10-10 (+2890d) |  |  |  |  | resources Doug Hampton [50%] → Douglas Henao [50%]; baseline start 2008-11-26 → 2016-09-16; baseline finish 2008-12-15 → 2016-10-04 |
| 41 | Archivado de imagen y sonido finales | 2008-11-11 → 2016-10-11 (+2891d) | 2008-11-13 → 2016-10-13 (+2891d) | 2d → 2.25d |  |  |  | resources Doug Hampton [50%]; Laboratorio de edición; Michael Patten → Douglas Henao [50%]; Laboratorio de edición; Miguel Pattoni; baseline start 2008-12-16 → 2016-10-04; baseline finish 2008-12-18 → 2016-10-06 |
| 42 | Entrega al distribuidor | 2008-11-13 → 2016-10-13 (+2891d) | 2008-11-14 → 2016-10-14 (+2891d) |  |  |  |  | resources Michael Patten → Miguel Pattoni; baseline start 2008-12-18 → 2016-10-07; baseline finish 2008-12-19 → 2016-10-07 |
