# Desarrollo MyWaySoftware 25

How a schedule from MS Project changed from version to version. A marks actual dates.

## Version 1 (data date 2015-05-01, saved 2015-01-15, file P-002.mpp)

| ID | WBS | Task | Duration | Start | Finish | Predecessors | Complete | Total float | Constraint |
| --- | --- | --- | --- | --- | --- | --- | --- | --- | --- |
| 1 | 1 | **Análisis de Requerimientos** | 14d | 2015-05-04 A | 2015-05-21 A |  | 100% |  |  |
| 2 |  | Realizar Análisis de Requerimientos | 4d | 2015-05-04 A | 2015-05-07 A |  | 100% |  | finish no later than 2015-05-08 |
| 3 |  | Realizar Especificaciones del Software | 6d | 2015-05-08 A | 2015-05-15 A | 2 | 100% |  |  |
| 4 |  | Desarrollar Presupuesto | 1.8d | 2015-05-18 A | 2015-05-19 A | 3 | 100% |  |  |
| 5 |  | Realizar Cronograma de Desarrollo | 3d | 2015-05-18 A | 2015-05-21 A | 4 | 100% |  |  |
| 6 |  | Fin Proceso de Análisis | 0d | 2015-05-25 A | 2015-05-25 A | 5 | 100% |  |  |
| 7 | 3 | **Diseño** | 13d | 2015-05-25 A | 2015-06-10 A |  | 100% |  |  |
| 8 |  | Desarrollar Especificaciones Funcionales | 9d | 2015-05-25 A | 2015-06-05 A | 6 | 100% |  | start no earlier than 2015-05-17 |
| 9 |  | Desarrollar Prototipo | 3d | 2015-06-08 A | 2015-06-10 A | 8 | 100% |  |  |
| 10 |  | Fin Proceso de Diseño | 0d | 2015-06-09 A | 2015-06-09 A | 9 | 100% |  |  |
| 11 | 5 | **Desarrollo** | 25d | 2015-06-10 A | 2015-07-14 |  | 18% | 21d |  |
| 12 |  | Identificar Parámetros de Diseño | 1d | 2015-06-10 A | 2015-06-10 A | 10 | 100% |  |  |
| 13 |  | Desarrollar Programación | 21d | 2015-06-15 A | 2015-07-13 | 12 | 14% | 22d |  |
| 14 |  | Realizar Pruebas del Software - Programador | 22d | 2015-06-15 A | 2015-07-14 | 13SS+1d | 18% | 3d |  |
| 15 |  | Fin Proceso de Desarrollo | 0d | 2015-07-14 | 2015-07-14 | 14 |  | 3d |  |
| 16 | 7 | **Pruebas** | 17d | 2015-07-15 | 2015-08-06 |  |  | 4d |  |
| 17 |  | Realizar Pruebas por Módulos | 5d | 2015-07-15 | 2015-07-21 | 15 |  | 4d | start no earlier than 2015-07-11 |
| 18 |  | Realizar Pruebas Integrales | 2d | 2015-07-22 | 2015-07-23 | 17 |  | 4d |  |
| 19 |  | Identificar Anomalías a las Especificaciones del Software | 3d | 2015-07-24 | 2015-07-28 | 18 |  | 4d |  |
| 20 |  | Realizar Ajustes | 5d | 2015-07-29 | 2015-08-04 | 19 |  | 4d |  |
| 21 |  | Realizar Pruebas a Ajustes Realizados | 2d | 2015-08-05 | 2015-08-06 | 20 |  | 4d |  |
| 22 |  | Fin Proceso de Pruebas | 0d | 2015-08-13 | 2015-08-13 | 21 |  | 0d | must finish on 2015-08-13 |

## Version 2 (data date 2015-05-31, saved 2015-01-15, file P-003.mpp)

Last finish 2015-08-13 → 2015-09-14 (+32d).

Changed:

| ID | Task | Start | Finish | Duration | Complete | Total float | Other |
| --- | --- | --- | --- | --- | --- | --- | --- |
| 1 | **Análisis de Requerimientos** | 2015-05-04 A → 2015-06-03 A (+30d) | 2015-05-21 A → 2015-06-22 A (+32d) |  |  |  | baseline start 2012-05-02 → 2015-05-04; baseline finish 2012-05-23 → 2015-05-21 |
| 2 | Realizar Análisis de Requerimientos | 2015-05-04 A → 2015-06-03 A (+30d) | 2015-05-07 A → 2015-06-08 A (+32d) |  |  |  | constraint finish no later than 2015-05-08 → finish no later than 2015-06-07; baseline start 2012-05-02 → 2015-05-04; baseline finish 2012-05-07 → 2015-05-07 |
| 3 | Realizar Especificaciones del Software | 2015-05-08 A → 2015-06-08 A (+31d) | 2015-05-15 A → 2015-06-15 A (+31d) |  |  |  | baseline start 2012-05-08 → 2015-05-08; baseline finish 2012-05-15 → 2015-05-15 |
| 4 | Desarrollar Presupuesto | 2015-05-18 A → 2015-06-17 A (+30d) | 2015-05-19 A → 2015-06-18 A (+30d) |  |  |  | baseline start 2012-05-16 → 2015-05-18; baseline finish 2012-05-17 → 2015-05-19 |
| 5 | Realizar Cronograma de Desarrollo | 2015-05-18 A → 2015-06-17 A (+30d) | 2015-05-21 A → 2015-06-22 A (+32d) |  |  |  | baseline start 2012-05-18 → 2015-05-18; baseline finish 2012-05-23 → 2015-05-21 |
| 6 | Fin Proceso de Análisis | 2015-05-25 A → 2015-06-24 A (+30d) | 2015-05-25 A → 2015-06-24 A (+30d) |  |  |  | baseline start 2012-05-23 → 2015-05-25; baseline finish 2012-05-23 → 2015-05-25 |
| 7 | **Diseño** | 2015-05-25 A → 2015-06-24 A (+30d) | 2015-06-10 A → 2015-07-14 A (+34d) | 13d → 15d |  |  | baseline start 2012-05-24 → 2015-05-25; baseline finish 2012-06-11 → 2015-06-10 |
| 8 | Desarrollar Especificaciones Funcionales | 2015-05-25 A → 2015-06-24 A (+30d) | 2015-06-05 A → 2015-07-08 A (+33d) | 9d → 10d |  |  | constraint start no earlier than 2015-05-17 → start no earlier than 2015-06-16; baseline start 2012-05-24 → 2015-05-25; baseline finish 2012-06-07 → 2015-06-05 |
| 9 | Desarrollar Prototipo | 2015-06-08 A → 2015-07-09 A (+31d) | 2015-06-10 A → 2015-07-14 A (+34d) | 3d → 4d |  |  | baseline start 2012-06-07 → 2015-06-08; baseline finish 2012-06-11 → 2015-06-10 |
| 10 | Fin Proceso de Diseño | 2015-06-09 A → 2015-07-14 A (+35d) | 2015-06-09 A → 2015-07-14 A (+35d) |  |  |  | baseline start 2012-06-09 → 2015-06-09; baseline finish 2012-06-09 → 2015-06-09 |
| 11 | **Desarrollo** | 2015-06-10 A → 2015-07-16 A (+36d) | 2015-07-14 → 2015-08-17 (+34d) | 25d → 23d | 18% → 19% | 21d → 19d | baseline start 2012-06-10 → 2015-06-10; baseline finish 2012-07-16 → 2015-07-14 |
| 12 | Identificar Parámetros de Diseño | 2015-06-10 A → 2015-07-16 A (+36d) | 2015-06-10 A → 2015-07-17 A (+37d) | 1d → 2d |  |  | baseline start 2012-06-10 → 2015-06-10; baseline finish 2012-06-11 → 2015-06-10 |
| 13 | Desarrollar Programación | 2015-06-15 A → 2015-07-16 A (+31d) | 2015-07-13 → 2015-08-14 (+32d) | 21d → 22d |  | 22d → 20d | baseline start 2012-06-13 → 2015-06-15; baseline finish 2012-07-12 → 2015-07-13 |
| 14 | Realizar Pruebas del Software - Programador | 2015-06-15 A → 2015-07-16 A (+31d) | 2015-07-14 → 2015-08-17 (+34d) | 22d → 23d | 18% → 17% | 3d → 0d | baseline start 2012-06-14 → 2015-06-15; baseline finish 2012-07-16 → 2015-07-14 |
| 15 | Fin Proceso de Desarrollo | 2015-07-14 → 2015-08-17 (+34d) | 2015-07-14 → 2015-08-17 (+34d) |  |  | 3d → 0d | baseline start 2012-07-16 → 2015-07-14; baseline finish 2012-07-16 → 2015-07-14 |
| 16 | **Pruebas** | 2015-07-15 → 2015-08-18 (+34d) | 2015-08-06 → 2015-09-11 (+36d) | 17d → 19d |  | 4d → 0d | baseline start 2012-07-16 → 2015-07-15; baseline finish 2012-08-08 → 2015-08-06 |
| 17 | Realizar Pruebas por Módulos | 2015-07-15 → 2015-08-18 (+34d) | 2015-07-21 → 2015-08-25 (+35d) | 5d → 6d |  | 4d → 0d | constraint start no earlier than 2015-07-11 → start no earlier than 2015-08-10; baseline start 2012-07-16 → 2015-07-15; baseline finish 2012-07-23 → 2015-07-21 |
| 18 | Realizar Pruebas Integrales | 2015-07-22 → 2015-08-26 (+35d) | 2015-07-23 → 2015-08-27 (+35d) |  |  | 4d → 0d | baseline start 2012-07-23 → 2015-07-22; baseline finish 2012-07-25 → 2015-07-23 |
| 19 | Identificar Anomalías a las Especificaciones del Software | 2015-07-24 → 2015-08-28 (+35d) | 2015-07-28 → 2015-09-01 (+35d) |  |  | 4d → 0d | baseline start 2012-07-25 → 2015-07-24; baseline finish 2012-07-30 → 2015-07-28 |
| 20 | Realizar Ajustes | 2015-07-29 → 2015-09-02 (+35d) | 2015-08-04 → 2015-09-08 (+35d) |  |  | 4d → 0d | baseline start 2012-07-30 → 2015-07-29; baseline finish 2012-08-06 → 2015-08-04 |
| 21 | Realizar Pruebas a Ajustes Realizados | 2015-08-05 → 2015-09-09 (+35d) | 2015-08-06 → 2015-09-11 (+36d) | 2d → 3d |  | 4d → 0d | baseline start 2012-08-06 → 2015-08-05; baseline finish 2012-08-08 → 2015-08-06 |
| 22 | Fin Proceso de Pruebas | 2015-08-13 → 2015-09-14 (+32d) | 2015-08-13 → 2015-09-14 (+32d) |  |  |  | constraint must finish on 2015-08-13 → must finish on 2015-09-14; baseline start 2012-08-12 → 2015-08-13; baseline finish 2012-08-12 → 2015-08-13 |
