# Develop CRM Software 30

How a schedule from MS Project changed from version to version. A marks actual dates.

## Version 1 (data date 2012-05-01, saved 2025-05-14, file ProAV-Unidad4-CRMSoftwareDevelopment30.mpp)

| ID | WBS | Task | Duration | Start | Finish | Predecessors | Complete | Total float | Constraint |
| --- | --- | --- | --- | --- | --- | --- | --- | --- | --- |
| 1 | 1 | **Analysis/Software Requirements** | 16d | 2012-05-02 A | 2012-05-23 A |  | 100% |  |  |
| 2 |  | Conduct needs analysis | 4d | 2012-05-02 A | 2012-05-07 A |  | 100% |  | finish no later than 2012-05-06 |
| 3 |  | Draft software specifications | 6d | 2012-05-08 A | 2012-05-15 A | 2 | 100% |  |  |
| 4 |  | Develop budget | 1.8d | 2012-05-16 A | 2012-05-17 A | 3 | 100% |  |  |
| 5 |  | Develop delivery timeline | 3d | 2012-05-18 A | 2012-05-23 A | 4 | 100% |  |  |
| 6 |  | Analysis complete | 0d | 2012-05-23 A | 2012-05-23 A | 5 | 100% |  |  |
| 7 | 3 | **Design** | 12d | 2012-05-24 A | 2012-06-11 A |  | 100% |  |  |
| 8 |  | Develop functional specifications | 9d | 2012-05-24 A | 2012-06-07 A | 6 | 100% |  | start no earlier than 2012-05-16 |
| 9 |  | Develop prototype based on functional specifications | 3d | 2012-06-07 A | 2012-06-11 A | 8 | 100% |  |  |
| 10 |  | Design complete | 0d | 2012-06-09 A | 2012-06-09 A | 9 | 100% |  |  |
| 11 | 5 | **Development** | 28d | 2012-06-10 A | 2012-07-19 |  | 17% | 17d |  |
| 12 |  | Identify design parameters | 1d | 2012-06-10 A | 2012-06-11 A | 10 | 100% |  |  |
| 13 |  | Develop code | 21d | 2012-06-13 A | 2012-07-12 | 12 | 14% | 22d |  |
| 14 |  | Developer testing (primary debugging) | 24.88d | 2012-06-14 A | 2012-07-19 | 13SS+1d | 16% | 0d | finish no earlier than 2012-07-19 |
| 15 |  | Development complete | 0d | 2012-07-19 | 2012-07-19 | 14 |  | 0d |  |
| 16 | 7 | **Testing** | 17d | 2012-07-20 | 2012-08-13 |  |  | 0d |  |
| 17 |  | Review modular code | 5d | 2012-07-20 | 2012-07-26 | 15 |  | 0d | start no earlier than 2012-07-11 |
| 18 |  | Test component modules to product specifications | 2d | 2012-07-27 | 2012-07-30 | 17 |  | 0d |  |
| 19 |  | Identify anomalies to product specifications | 3d | 2012-07-31 | 2012-08-02 | 18 |  | 0d |  |
| 20 |  | Modify code | 5d | 2012-08-03 | 2012-08-09 | 19 |  | 0d |  |
| 21 |  | Re-test modified code | 2d | 2012-08-10 | 2012-08-13 | 20 |  | 0d |  |
| 22 |  | Testing Complete | 0d | 2012-08-13 | 2012-08-13 | 21 |  | 0d |  |

## Version 2 (data date 2012-05-01, saved 2025-05-14, file ProAV-Unidad4-CRMSoftwareDevelopment25.mpp)

Last finish 2012-08-13 → 2012-08-12 (-1d).

Changed:

| ID | Task | Start | Finish | Duration | Complete | Total float | Other |
| --- | --- | --- | --- | --- | --- | --- | --- |
| 11 | **Development** |  | 2012-07-19 → 2012-07-16 (-3d) | 28d → 25d | 17% → 18% | 17d → 19d |  |
| 14 | Developer testing (primary debugging) |  | 2012-07-19 → 2012-07-16 (-3d) | 24.88d → 22d | 16% → 18% | 0d → 2d | constraint finish no earlier than 2012-07-19 → none |
| 15 | Development complete | 2012-07-19 → 2012-07-16 (-3d) | 2012-07-19 → 2012-07-16 (-3d) |  |  | 0d → 2d |  |
| 16 | **Testing** | 2012-07-20 → 2012-07-17 (-3d) | 2012-08-13 → 2012-08-08 (-5d) |  |  | 0d → 2d | baseline start 2012-07-17 → 2012-07-16 |
| 17 | Review modular code | 2012-07-20 → 2012-07-17 (-3d) | 2012-07-26 → 2012-07-23 (-3d) |  |  | 0d → 2d | baseline start 2012-07-17 → 2012-07-16 |
| 18 | Test component modules to product specifications | 2012-07-27 → 2012-07-24 (-3d) | 2012-07-30 → 2012-07-25 (-5d) |  |  | 0d → 2d | baseline start 2012-07-24 → 2012-07-23 |
| 19 | Identify anomalies to product specifications | 2012-07-31 → 2012-07-26 (-5d) | 2012-08-02 → 2012-07-30 (-3d) |  |  | 0d → 2d | baseline start 2012-07-26 → 2012-07-25 |
| 20 | Modify code | 2012-08-03 → 2012-07-31 (-3d) | 2012-08-09 → 2012-08-06 (-3d) |  |  | 0d → 2d | baseline start 2012-07-31 → 2012-07-30 |
| 21 | Re-test modified code | 2012-08-10 → 2012-08-07 (-3d) | 2012-08-13 → 2012-08-08 (-5d) |  |  | 0d → 2d | baseline start 2012-08-07 → 2012-08-06 |
| 22 | Testing Complete | 2012-08-13 → 2012-08-12 (-1d) | 2012-08-13 → 2012-08-12 (-1d) |  |  |  | constraint none → must finish on 2012-08-12 |
